# productieschema overheids-procedures

Schedule from MS Project, 2002-12-30 to 2005-02-04.
BAM Nelissen Van Egteren

## Calendars

- Standaard: Mon-Fri 08:30-12:30, 13:00-17:00; Sat-Sun off.

## Schedule

| ID | WBS | Task | Type | Duration | Start | Finish | Predecessors | Total slack | Free slack |
| --- | --- | --- | --- | --- | --- | --- | --- | --- | --- |
| 1 | 1 | **BOUWVERGUNNING (geen bezwaar)** |  | 105d | 2002-12-30 | 2003-05-23 |  | 445d |  |
| 2 | 1.1 | indienen bouwaanvraag | milestone | 0w | 2002-12-30 | 2002-12-30 |  | 310d | 0d |
| 3 | 1.2 | behandeling aanvraag gemeente |  | 13w | 2002-12-30 | 2003-03-28 | 2 | 310d | 0d |
| 4 | 1.3 | bekendmaking verlening vergunning |  | 1w | 2003-03-31 | 2003-04-04 | 3 | 310d | 0d |
| 5 | 1.4 | besluit ter inzage leggen |  | 1w | 2003-04-07 | 2003-04-11 | 4 | 310d | 0d |
| 6 | 1.5 | termijn voor bezwaar (geen bezwaren) |  | 6w | 2003-04-14 | 2003-05-23 | 5 | 310d | 0d |
| 7 | 1.6 | bouwbesluit onherroepelijk | milestone | 0w | 2003-05-23 | 2003-05-23 | 6 | 310d |  |
| 9 | 2 | **BOUWVERGUNNING (met bezwaar)** |  | 460d | 2002-12-30 | 2004-10-01 |  | 90d |  |
| 10 | 2.1 | indienen bouwaanvraag | milestone | 0w | 2002-12-30 | 2002-12-30 |  | 90d | 0d |
| 11 | 2.2 | behandeling aanvraag gemeente |  | 13w | 2002-12-30 | 2003-03-28 | 10 | 90d | 0d |
| 12 | 2.3 | bekendmaking verlening vergunning |  | 1w | 2003-03-31 | 2003-04-04 | 11 | 90d | 0d |
| 13 | 2.4 | besluit ter inzage leggen | milestone | 0w | 2003-04-04 | 2003-04-04 | 12 | 90d | 0d |
| 14 | 2.5 | termijn voor bezwaar |  | 6w | 2003-04-07 | 2003-05-16 | 13SS | 90d | 0d |
| 15 | 2.6 | verzoek voorl. voorziening rechtbank |  | 6w | 2003-04-07 | 2003-05-16 | 13SS | 425d | 0d |
| 16 | 2.7 | behandeling verzoek voorl.voorziening |  | 4w | 2003-05-19 | 2003-06-13 | 15 | 425d | 0d |
| 17 | 2.8 | uitspraak rechbank voorl.voorziening |  | 1w | 2003-06-16 | 2003-06-20 | 16 | 425d |  |
| 18 | 2.9 | behandeling bezwaarschrift commissie |  | 19w | 2003-05-19 | 2003-09-26 | 14 | 90d | 0d |
| 19 | 2.10 | beslissing bezwaar gemeenteraad |  | 1w | 2003-09-29 | 2003-10-03 | 18 | 90d | 0d |
| 20 | 2.11 | bekendmaking beslissing op bezwaar |  | 1w | 2003-10-06 | 2003-10-10 | 19 | 90d | 0d |
| 21 | 2.12 | beroep+voorl.voorz. Rechtbank |  | 6w | 2003-10-13 | 2003-11-21 | 20 | 90d | 0d |
| 22 | 2.13 | behandeling verzoek voorl.voorz.rechtbank |  | 4w | 2003-11-24 | 2003-12-19 | 21 | 90d | 0d |
| 23 | 2.14 | uitspraak rechtbank voorl.voorz. |  | 1w | 2003-12-22 | 2003-12-26 | 22 | 90d | 0d |
| 24 | 2.15 | beroepsprocedure bij rechtbank |  | 40w | 2003-12-29 | 2004-10-01 | 23 | 90d | 0d |
| 25 | 2.16 | uitspraak voorl.voorz.rechtbank | milestone | 0w | 2004-10-01 | 2004-10-01 | 24 | 90d |  |

| ID | WBS | Task | Type | Duration | Start | Finish | Predecessors | Total slack | Free slack |
| --- | --- | --- | --- | --- | --- | --- | --- | --- | --- |
| 26 | 3 | **beroepsprocedure bij Raad van State** |  | 295d | 2002-12-30 | 2004-02-13 |  | 255d |  |
| 27 | 3.1 | hoger beroep+verzoek voor.voorz. ABRvs |  | 6w | 2002-12-30 | 2003-02-07 |  | 255d | 0d |
| 28 | 3.2 | behandeling beroep bij ABRvS |  | 13w | 2003-02-10 | 2003-05-09 | 27 | 450d | 0d |
| 29 | 3.3 | uitsprraak voorzitter ABRvS |  | 1w | 2003-05-12 | 2003-05-16 | 28 | 450d |  |
| 30 | 3.4 | beroepsprocedure bij ABRvS |  | 52w | 2003-02-10 | 2004-02-06 | 27 | 255d | 0d |
| 31 | 3.5 | uitspraak verwerping beroep ABRvS |  | 1w | 2004-02-09 | 2004-02-13 | 30 | 255d | 0d |
| 32 | 3.6 | bouwvergunning onherroepelijk | milestone | 0w | 2004-02-13 | 2004-02-13 | 31 | 255d |  |
| 34 | 4 | **SLOOP-VERGUNNING (met bezwaar)** |  | 430d | 2002-12-30 | 2004-08-20 |  | 120d |  |
| 35 | 4.1 | indienen sloop-aanvraag | milestone | 0w | 2002-12-30 | 2002-12-30 |  | 120d | 0d |
| 36 | 4.2 | behandeling aanvraag sloopvergunning |  | 13w | 2002-12-30 | 2003-03-28 | 35 | 120d | 0d |
| 37 | 4.3 | besluit sloopvergunning ter inzage |  | 1w | 2003-03-31 | 2003-04-04 | 36 | 120d | 0d |
| 38 | 4.4 | termijn voor bezwaren |  | 6w | 2003-03-31 | 2003-05-09 | 37SS | 455d |  |
| 39 | 4.5 | indiening verzoek voorl.voorz. Rechtbank |  | 6w | 2003-03-31 | 2003-05-09 | 37SS | 120d | 0d |
| 40 | 4.6 | behandeling verzoek voorl.voorz. |  | 4w | 2003-05-12 | 2003-06-06 | 39 | 120d | 0d |
| 41 | 4.7 | uitspraak rechtbank voorl.voorz. (bezwaar) |  | 1w | 2003-06-09 | 2003-06-13 | 40 | 120d | 0d |
| 42 | 4.8 | behandeling bezwaarschrift door commissie |  | 10w | 2003-06-16 | 2003-08-22 | 41 | 120d | 0d |
| 43 | 4.9 | beslissing bezwaar door B & W | milestone | 0w | 2003-08-22 | 2003-08-22 | 42 | 120d | 0d |
| 44 | 4.10 | bekendmaking beslissing op bezwaar |  | 1w | 2003-08-25 | 2003-08-29 | 43 | 120d | 0d |
| 45 | 4.11 | beroep+voorl.voorz. Rechtbank |  | 6w | 2003-09-01 | 2003-10-10 | 44 | 120d | 0d |
| 46 | 4.12 | behandeling voorl.voorz. Rechtbank |  | 4w | 2003-10-13 | 2003-11-07 | 45 | 120d | 0d |
| 47 | 4.13 | uitspraak rechtbank voorl.voorz. |  | 1w | 2003-11-10 | 2003-11-14 | 46 | 120d | 0d |
| 48 | 4.14 | beroepsprocedure bij rechtbank |  | 40w | 2003-11-17 | 2004-08-20 | 47 | 120d | 0d |
| 49 | 4.15 | uitspraak rechtbank voorl.voorz. | milestone | 0w | 2004-08-20 | 2004-08-20 | 48 | 120d |  |
| 50 | 5 | **beroepsprocedure bij Raad va State** |  | 295d | 2002-12-30 | 2004-02-13 |  | 255d |  |
| 51 | 5.1 | hoger beroep+verzoek voorl.voorz. Bij ABRvS |  | 6w | 2002-12-30 | 2003-02-07 |  | 255d | 0d |
| 52 | 5.2 | behandeling verzoek voorl.voorz. ABRvS |  | 13w | 2003-02-10 | 2003-05-09 | 51 | 450d | 0d |
| 53 | 5.3 | uitspraak door voorzitter ABRvS |  | 1w | 2003-05-12 | 2003-05-16 | 52 | 450d |  |
| 54 | 5.4 | beroepsprocedure bij ABRvS |  | 52w | 2003-02-10 | 2004-02-06 | 51 | 255d | 0d |
| 55 | 5.5 | uitspraak verwerping beroep ABRvS |  | 1w | 2004-02-09 | 2004-02-13 | 54 | 255d | 0d |
| 56 | 5.6 | sloopvergunning onherroepelijk | milestone | 0w | 2004-02-13 | 2004-02-13 | 55 | 255d |  |

| ID | WBS | Task | Type | Duration | Start | Finish | Predecessors | Total slack | Free slack |
| --- | --- | --- | --- | --- | --- | --- | --- | --- | --- |
| 58 | 6 | **KAP-VERGUNNING (met bezwaar)** |  | 405d | 2002-12-30 | 2004-07-16 |  | 145d |  |
| 59 | 6.1 | indienen aanvraag kapvergunning | milestone | 0w | 2002-12-30 | 2002-12-30 |  | 145d | 0d |
| 60 | 6.2 | behandeling aanvraag sloopvergunning |  | 13w | 2002-12-30 | 2003-03-28 | 59 | 145d | 0d |
| 61 | 6.3 | besluit sloopvergunning ter inzage |  | 1w | 2003-03-31 | 2003-04-04 | 60 | 145d | 0d |
| 62 | 6.4 | termijn voor bezwaren |  | 6w | 2003-03-31 | 2003-05-09 | 61SS | 145d | 0d |
| 63 | 6.5 | indiening verzoek voorl.voorz. Rechtbank |  | 6w | 2003-03-31 | 2003-05-09 | 61SS | 430d | 0d |
| 64 | 6.6 | behandeling verzoek voorl.voorz. |  | 4w | 2003-05-12 | 2003-06-06 | 63 | 430d | 0d |
| 65 | 6.7 | uitspraak rechtbank voorl.voorz. (bezwaar) |  | 1w | 2003-06-09 | 2003-06-13 | 64 | 430d |  |
| 66 | 6.8 | behandeling bezwaarschrift door commissie |  | 10w | 2003-05-12 | 2003-07-18 | 62 | 145d | 0d |
| 67 | 6.9 | beslissing bezwaar door B & W | milestone | 0w | 2003-07-18 | 2003-07-18 | 66 | 145d | 0d |
| 68 | 6.10 | bekendmaking beslissing op bezwaar |  | 1w | 2003-07-21 | 2003-07-25 | 67 | 145d | 0d |
| 69 | 6.11 | beroep+voorl.voorz. Rechtbank |  | 6w | 2003-07-28 | 2003-09-05 | 68 | 145d | 0d |
| 70 | 6.12 | behandeling voorl.voorz. Rechtbank |  | 4w | 2003-09-08 | 2003-10-03 | 69 | 145d | 0d |
| 71 | 6.13 | uitspraak rechtbank voorl.voorz. |  | 1w | 2003-10-06 | 2003-10-10 | 70 | 145d | 0d |
| 72 | 6.14 | beroepsprocedure bij rechtbank |  | 40w | 2003-10-13 | 2004-07-16 | 71 | 145d | 0d |
| 73 | 6.15 | uitspraak rechtbank voorl.voorz. | milestone | 0w | 2004-07-16 | 2004-07-16 | 72 | 145d |  |
| 74 | 7 | **beroepsprocedure bij Raad van State** |  | 295d | 2002-12-30 | 2004-02-13 |  | 255d |  |
| 75 | 7.1 | hoger beroep+verzoek voorl.voorz. ABRvS |  | 6w | 2002-12-30 | 2003-02-07 |  | 255d | 0d |
| 76 | 7.2 | behandeling verzoek voorl.voorz. ABRvS |  | 13w | 2003-02-10 | 2003-05-09 | 75 | 450d | 0d |
| 77 | 7.3 | uitspraak door voorzitter ABRvS |  | 1w | 2003-05-12 | 2003-05-16 | 76 | 450d |  |
| 78 | 7.4 | beroepsprocedure bij ABRvS |  | 52w | 2003-02-10 | 2004-02-06 | 75 | 255d | 0d |
| 79 | 7.5 | uitspraak verwerping beroep ABRvS |  | 1w | 2004-02-09 | 2004-02-13 | 78 | 255d | 0d |
| 80 | 7.6 | sloopvergunning onherroepelijk | milestone | 0w | 2004-02-13 | 2004-02-13 | 79 | 255d |  |
| 82 | 8 | **AANLEG-VERGUNNING (met bezwaar)** |  | 430d | 2002-12-30 | 2004-08-20 |  | 120d |  |
| 83 | 8.1 | indienen aanvraag aanlegvergunning | milestone | 0w | 2002-12-30 | 2002-12-30 |  | 120d | 0d |
| 84 | 8.2 | behandeling aanvraag sloopvergunning |  | 13w | 2002-12-30 | 2003-03-28 | 83 | 120d | 0d |
| 85 | 8.3 | besluit sloopvergunning ter inzage |  | 1w | 2003-03-31 | 2003-04-04 | 84 | 120d | 0d |
| 86 | 8.4 | termijn voor bezwaren |  | 6w | 2003-03-31 | 2003-05-09 | 85SS | 455d |  |
| 87 | 8.5 | indiening verzoek voorl.voorz. Rechtbank |  | 6w | 2003-03-31 | 2003-05-09 | 85SS | 120d | 0d |
| 88 | 8.6 | behandeling verzoek voorl.voorz. |  | 4w | 2003-05-12 | 2003-06-06 | 87 | 120d | 0d |
| 89 | 8.7 | uitspraak rechtbank voorl.voorz. (bezwaar) |  | 1w | 2003-06-09 | 2003-06-13 | 88 | 120d | 0d |
| 90 | 8.8 | behandeling bezwaarschrift door commissie |  | 10w | 2003-06-16 | 2003-08-22 | 89 | 120d | 0d |
| 91 | 8.9 | beslissing bezwaar door B & W | milestone | 0w | 2003-08-22 | 2003-08-22 | 90 | 120d | 0d |
| 92 | 8.10 | bekendmaking beslissing op bezwaar |  | 1w | 2003-08-25 | 2003-08-29 | 91 | 120d | 0d |
| 93 | 8.11 | beroep+voorl.voorz. Rechtbank |  | 6w | 2003-09-01 | 2003-10-10 | 92 | 120d | 0d |
| 94 | 8.12 | behandeling voorl.voorz. Rechtbank |  | 4w | 2003-10-13 | 2003-11-07 | 93 | 120d | 0d |
| 95 | 8.13 | uitspraak rechtbank voorl.voorz. |  | 1w | 2003-11-10 | 2003-11-14 | 94 | 120d | 0d |
| 96 | 8.14 | beroepsprocedure bij rechtbank |  | 40w | 2003-11-17 | 2004-08-20 | 95 | 120d | 0d |
| 97 | 8.15 | uitspraak rechtbank voorl.voorz. | milestone | 0w | 2004-08-20 | 2004-08-20 | 96 | 120d |  |

| ID | WBS | Task | Type | Duration | Start | Finish | Predecessors | Total slack | Free slack |
| --- | --- | --- | --- | --- | --- | --- | --- | --- | --- |
| 98 | 9 | **beroepsprocedure bij Raad van State** |  | 295d | 2002-12-30 | 2004-02-13 |  | 255d |  |
| 99 | 9.1 | hoger beroep+verzoek voorl.voorz. Bij ABRvS |  | 6w | 2002-12-30 | 2003-02-07 |  | 255d | 0d |
| 100 | 9.2 | behandeling verzoek voorl.voorz. ABRvS |  | 13w | 2003-02-10 | 2003-05-09 | 99 | 450d | 0d |
| 101 | 9.3 | uitspraak door voorzitter ABRvS |  | 1w | 2003-05-12 | 2003-05-16 | 100 | 450d |  |
| 102 | 9.4 | beroepsprocedure bij ABRvS |  | 52w | 2003-02-10 | 2004-02-06 | 99 | 255d | 0d |
| 103 | 9.5 | uitspraak verwerping beroep ABRvS |  | 1w | 2004-02-09 | 2004-02-13 | 102 | 255d | 0d |
| 104 | 9.6 | sloopvergunning onherroepelijk | milestone | 0w | 2004-02-13 | 2004-02-13 | 103 | 255d |  |
| 106 | 10 | **UITWERKINGSPLAN ART. 11 (geen bezwaar)** |  | 105d | 2002-12-30 | 2003-05-23 |  | 445d |  |
| 107 | 10.1 | behandeling voorontwerp |  | 6w | 2002-12-30 | 2003-02-07 |  | 445d | 0d |
| 108 | 10.2 | behandeling ontwerp in B & W |  | 1w | 2003-02-10 | 2003-02-14 | 107 | 445d | 0d |
| 109 | 10.3 | publicatie ontwerp uitwerkingsplan |  | 2w | 2003-02-17 | 2003-02-28 | 108 | 445d | 0d |
| 110 | 10.4 | uitwerkingsplan ter inzage leggen |  | 1w | 2003-03-03 | 2003-03-07 | 109 | 445d | 0d |
| 111 | 10.5 | bedenkingen B & W tegen ontwerp |  | 2w | 2003-03-03 | 2003-03-14 | 110SS | 445d | 0d |
| 112 | 10.6 | opstellen ambtelijk advies reacties |  | 2w | 2003-03-17 | 2003-03-28 | 111 | 445d | 0d |
| 113 | 10.7 | besluit B & W vaststellen uitwerkingsplan |  | 2w | 2003-03-31 | 2003-04-11 | 112 | 445d | 0d |
| 114 | 10.8 | besluit B & W ter inzage leggen |  | 6w | 2003-04-14 | 2003-05-23 | 113 | 445d |  |
| 115 | 10.9 | beroepstermijn op besluit B & W |  | 6w | 2003-04-14 | 2003-05-23 | 113 | 445d | 0d |
| 116 | 10.10 | uitwerkingsplan onherroepelijk | milestone | 0w | 2003-05-23 | 2003-05-23 | 115 | 445d |  |
| 118 | 11 | **UITWERKINGSPLAN ART. 11 (goedk .GS)** |  | 200d | 2002-12-30 | 2003-10-03 |  | 350d |  |
| 119 | 11.1 | behandeling voorontwerp |  | 6w | 2002-12-30 | 2003-02-07 |  | 350d | 0d |
| 120 | 11.2 | behandeling ontwerp in B & W |  | 1w | 2003-02-10 | 2003-02-14 | 119 | 350d | 0d |
| 121 | 11.3 | publicatie ontwerp uitwerkingsplan |  | 2w | 2003-02-17 | 2003-02-28 | 120 | 350d | 0d |
| 122 | 11.4 | uitwerkingsplan ter inzage leggen |  | 2w | 2003-03-03 | 2003-03-14 | 121 | 350d | 0d |
| 123 | 11.5 | bedenkingen B & W tegen ontwerp |  | 2w | 2003-03-03 | 2003-03-14 | 122SS | 350d | 0d |
| 124 | 11.6 | opstellen ambtelijk advies reacties |  | 2w | 2003-03-17 | 2003-03-28 | 123 | 350d | 0d |
| 125 | 11.7 | besluit B & W vaststellen uitwerkingsplan |  | 2w | 2003-03-31 | 2003-04-11 | 124 | 350d | 0d |
| 126 | 11.8 | verzenden uitwerkingsplan aan GS |  | 2w | 2003-04-14 | 2003-04-25 | 125 | 350d | 0d |
| 127 | 11.9 | behandeling uitwerkingsplan door GS |  | 8w | 2003-04-28 | 2003-06-20 | 126 | 350d | 0d |
| 128 | 11.10 | besluit uitwerkingsplan door GS |  | 1w | 2003-06-23 | 2003-06-27 | 127 | 350d | 0d |
| 129 | 11.11 | besluit GS ter inzage door B & W |  | 6w | 2003-07-14 | 2003-08-22 | 128FS+2w | 350d | 0d |
| 130 | 11.12 | beroepstermijn besluit van GS |  | 6w | 2003-08-25 | 2003-10-03 | 129 | 350d | 0d |
| 131 | 11.13 | uitwerkingsplan onherroepelijk | milestone | 0w | 2003-10-03 | 2003-10-03 | 130 | 350d |  |

| ID | WBS | Task | Type | Duration | Start | Finish | Predecessors | Total slack | Free slack |
| --- | --- | --- | --- | --- | --- | --- | --- | --- | --- |
| 133 | 12 | **UITWERKINGSPLAN ART. 11 (wel bezwaar)** |  | 105d | 2002-12-30 | 2003-05-23 |  | 445d |  |
| 134 | 12.1 | behandeling voorontwerp |  | 6w | 2002-12-30 | 2003-02-07 |  | 445d | 0d |
| 135 | 12.2 | behandeling ontwerp in B & W |  | 1w | 2003-02-10 | 2003-02-14 | 134 | 445d | 0d |
| 136 | 12.3 | publicatie ontwerp uitwerkingsplan |  | 2w | 2003-02-17 | 2003-02-28 | 135 | 445d | 0d |
| 137 | 12.4 | uitwerkingsplan ter inzage leggen |  | 2w | 2003-03-03 | 2003-03-14 | 136 | 445d | 0d |
| 138 | 12.5 | bedenklingen B & W tegen ontwerp |  | 2w | 2003-03-03 | 2003-03-14 | 137SS | 445d | 0d |
| 139 | 12.6 | opstellen ambtelijk advies reacties |  | 2w | 2003-03-17 | 2003-03-28 | 138 | 445d | 0d |
| 140 | 12.7 | besluit B & W vaststellen uitwerkingsplan |  | 2w | 2003-03-31 | 2003-04-11 | 139 | 445d | 0d |
| 141 | 12.8 | besluit B & W ter inzage leggen |  | 6w | 2003-04-14 | 2003-05-23 | 140 | 445d |  |
| 142 | 12.9 | beroepstermijn besluit B & W |  | 6w | 2003-04-14 | 2003-05-23 | 140 | 445d |  |
| 143 | 13 | **beroepsprocedure bij Raad van State** |  | 265d | 2002-12-30 | 2004-01-02 |  | 285d |  |
| 144 | 13.1 | verzoek voor.voorz. Bij ABRvS |  | 1w | 2002-12-30 | 2003-01-03 |  | 285d | 0d |
| 145 | 13.2 | behandeling verzoek bij ABRvS |  | 13w | 2003-01-06 | 2003-04-04 | 144 | 475d | 0d |
| 146 | 13.3 | uitspraak op verzoek door ABRvS | milestone | 0w | 2003-04-04 | 2003-04-04 | 145 | 475d | 0d |
| 147 | 13.4 | van kracht zijnd uitwerkingsplan |  | 1w | 2003-04-07 | 2003-04-11 | 146 | 475d |  |
| 148 | 13.5 | beroepsprocedure ABRvS |  | 52w | 2003-01-06 | 2004-01-02 | 144 | 285d | 0d |
| 149 | 13.6 | uitwerkingsplan onheroepelijk | milestone | 0w | 2004-01-02 | 2004-01-02 | 148 | 285d |  |
| 151 | 14 | **UITWERKINGSPLAN ART.11 (GS met bezwaar)** |  | 195d | 2002-12-30 | 2003-09-26 |  | 355d |  |
| 152 | 14.1 | behandeling voorontwerp |  | 6w | 2002-12-30 | 2003-02-07 |  | 355d | 0d |
| 153 | 14.2 | behandeling ontwerp in B & W |  | 1w | 2003-02-10 | 2003-02-14 | 152 | 355d | 0d |
| 154 | 14.3 | publicatie ontwerp uitwerkingsplan |  | 2w | 2003-02-17 | 2003-02-28 | 153 | 355d | 0d |
| 155 | 14.4 | uitwerkingsplan ter inzage leggen |  | 2w | 2003-03-03 | 2003-03-14 | 154 | 355d | 0d |
| 156 | 14.5 | bedenkingen B & W tegen ontwerp |  | 2w | 2003-03-03 | 2003-03-14 | 155SS | 355d | 0d |
| 157 | 14.6 | opstellen ambtelijk advies reacties |  | 2w | 2003-03-17 | 2003-03-28 | 156 | 355d | 0d |
| 158 | 14.7 | besluit B & W vaststellen uitwerkingsplan |  | 2w | 2003-03-31 | 2003-04-11 | 157 | 355d | 0d |
| 159 | 14.8 | verzenden uitwerkingsplan naar GS |  | 2w | 2003-04-14 | 2003-04-25 | 158 | 355d | 0d |
| 160 | 14.9 | behandeling uitwerkingsplan door GS |  | 8w | 2003-04-28 | 2003-06-20 | 159 | 355d | 0d |
| 161 | 14.10 | besluit uitwerkingsplan door GS | milestone | 0w | 2003-06-20 | 2003-06-20 | 160 | 355d | 0d |
| 162 | 14.11 | besluit GS ter inzage door B & W |  | 6w | 2003-07-07 | 2003-08-15 | 161FS+2w | 355d | 0d |
| 163 | 14.12 | beroepstermijn uitwerkingsplan besluit GS |  | 6w | 2003-08-18 | 2003-09-26 | 162 | 355d |  |

| ID | WBS | Task | Type | Duration | Start | Finish | Predecessors | Total slack | Free slack |
| --- | --- | --- | --- | --- | --- | --- | --- | --- | --- |
| 164 | 15 | **Beroepsprocedure bij Raad van State** |  | 270d | 2002-12-30 | 2004-01-09 |  | 280d |  |
| 165 | 15.1 | beroep+verzoek voorl.voorz. Bij ABRvS |  | 1w | 2002-12-30 | 2003-01-03 |  | 280d | 0d |
| 166 | 15.2 | behandeling voorl.voorz. door ABRvS |  | 13w | 2003-01-06 | 2003-04-04 | 165 | 475d | 0d |
| 167 | 15.3 | uitspraak voorl.voorz. door voorz. ABRvS |  | 1w | 2003-04-07 | 2003-04-11 | 166 | 475d | 0d |
| 168 | 15.4 | van kracht zijnd uitwerkingsplan na afwijzing | milestone | 0w | 2003-04-11 | 2003-04-11 | 167 | 475d |  |
| 169 | 15.5 | beroepsprocedure bij ABRvS |  | 52w | 2003-01-06 | 2004-01-02 | 165 | 280d | 0d |
| 170 | 15.6 | uitspraak verwerping beroep door ABRvS |  | 1w | 2004-01-05 | 2004-01-09 | 169 | 280d | 0d |
| 171 | 15.7 | uitwerkingsplan onherroepelijk | milestone | 0w | 2004-01-09 | 2004-01-09 | 170 | 280d |  |
| 173 | 16 | **ARTIKEL 19 LID 1 WRO (geen bezwaar)** |  | 270d | 2002-12-30 | 2004-01-09 |  | 280d |  |
| 174 | 16.1 | concept verzoek vrijstelling bouwplan |  | 1w | 2002-12-30 | 2003-01-03 |  | 280d | 0d |
| 175 | 16.2 | inspraakprocedure art.6A WRO gemeentewet |  | 13w | 2003-01-06 | 2003-04-04 | 174 | 280d | 0d |
| 176 | 16.3 | indiening verzoek om vrijstelling |  | 1w | 2003-04-07 | 2003-04-11 | 175 | 280d | 0d |
| 177 | 16.4 | principebesluit toepassing vrijstellingsprocedure |  | 8w | 2003-04-14 | 2003-06-06 | 176 | 280d | 0d |
| 178 | 16.5 | kennisgeving ter inzage leggen |  | 1w | 2003-06-09 | 2003-06-13 | 177 | 280d | 0d |
| 179 | 16.6 | vrijstellingsverzoek ter inzage |  | 1w | 2003-06-16 | 2003-06-20 | 178 | 280d | 0d |
| 180 | 16.7 | indienen zienswijzen tegen vrijstellingsverzoek |  | 4w | 2003-06-16 | 2003-07-11 | 179SS | 390d | 0d |
| 181 | 16.8 | verwerken/beantwoorden zienswijzen |  | 4w | 2003-07-14 | 2003-08-08 | 180 | 390d |  |
| 182 | 16.9 | behandeling verzoek (gemeentebestuur) |  | 8w | 2003-06-23 | 2003-08-15 | 179 | 280d | 0d |
| 183 | 16.10 | besluit aanvragen VVGB bij GS |  | 1w | 2003-08-18 | 2003-08-22 | 182 | 280d | 0d |
| 184 | 16.11 | aanvraag verklaring geen bezwaar naar GS |  | 2w | 2003-08-25 | 2003-09-05 | 183 | 280d | 0d |
| 185 | 16.12 | besluit GS verlenen verklaring geen bezwaar |  | 8w | 2003-09-08 | 2003-10-31 | 184 | 280d | 0d |
| 186 | 16.13 | bekendmaking besluit GS aan gemeente |  | 2w | 2003-11-03 | 2003-11-14 | 185 | 280d | 0d |
| 187 | 16.14 | besluit gemeenteraad verlenen vrijstelling |  | 2w | 2003-11-17 | 2003-11-28 | 186 | 280d | 0d |
| 188 | 16.15 | bekendmaking primair besluit:rechtskracht | milestone | 0w | 2003-11-28 | 2003-11-28 | 187 | 280d | 0d |
| 189 | 16.16 | termijn voor bezwaren |  | 6w | 2003-12-01 | 2004-01-09 | 188 | 280d | 0d |
| 190 | 16.17 | onherroepelijke vrijstelling | milestone | 0w | 2004-01-09 | 2004-01-09 | 189 | 280d |  |

| ID | WBS | Task | Type | Duration | Start | Finish | Predecessors | Total slack | Free slack |
| --- | --- | --- | --- | --- | --- | --- | --- | --- | --- |
| 192 | 17 | **ARTIKEL 19 LID 1 wro (met bezwaar)** |  | 550d | 2002-12-30 | 2005-02-04 |  | 0d |  |
| 193 | 17.1 | concept vezoek vrijstelling bouwplan |  | 1w | 2002-12-30 | 2003-01-03 |  | 0d |  |
| 194 | 17.2 | inspraakprocedure art.6A WRO gemeentewet |  | 13w | 2003-01-06 | 2003-04-04 | 193 | 0d |  |
| 195 | 17.3 | indienen verzoek om vrijstelling |  | 1w | 2003-04-07 | 2003-04-11 | 194 | 0d |  |
| 196 | 17.4 | principe besluit toepassing vrijstelling |  | 8w | 2003-04-14 | 2003-06-06 | 195 | 0d |  |
| 197 | 17.5 | kennisgeving ter inzage leggen |  | 1w | 2003-06-09 | 2003-06-13 | 196 | 0d |  |
| 198 | 17.6 | verzoek vrijstelling ter inzage leggen |  | 1w | 2003-06-16 | 2003-06-20 | 197 | 0d |  |
| 199 | 17.7 | indienen zienswijzen tegen bouwplan |  | 4w | 2003-06-16 | 2003-07-11 | 198SS | 390d | 0d |
| 200 | 17.8 | beantwoorden zienswijzen |  | 4w | 2003-07-14 | 2003-08-08 | 199 | 390d |  |
| 201 | 17.9 | behandeling verzoek vrijstelling gemeenteraad |  | 8w | 2003-06-23 | 2003-08-15 | 198 | 0d |  |
| 202 | 17.10 | besluit omtrent aanvragen VVGB bij GS | milestone | 0w | 2003-08-15 | 2003-08-15 | 201 | 0d |  |
| 203 | 17.11 | aanvraag verklaring geen bezwaar naar GS |  | 2w | 2003-08-18 | 2003-08-29 | 202 | 0d |  |
| 204 | 17.12 | besluit GS verlenen verklaring geen bezwaar |  | 8w | 2003-09-01 | 2003-10-24 | 203 | 0d |  |
| 205 | 17.13 | bekendmaking besluit GS aan gemeente |  | 2w | 2003-10-27 | 2003-11-07 | 204 | 0d |  |
| 206 | 17.14 | besluit gemeenteraad verlenen vrijstelling |  | 2w | 2003-11-10 | 2003-11-21 | 205 | 0d |  |
| 207 | 17.15 | bekendmaking primair besluit: rechtskracht |  | 1w | 2003-11-24 | 2003-11-28 | 206 | 0d |  |
| 208 | 17.16 | beroepsprocedure bij Voorz. Rechtbank | milestone | 0w | 2003-11-28 | 2003-11-28 | 207 | 0d |  |
| 209 | 17.17 | termijn van bezwaren |  | 6w | 2003-12-01 | 2004-01-09 | 208 | 280d |  |
| 210 | 17.18 | indienen verzoek vrijstelling bij Rechtbank |  | 6w | 2003-12-01 | 2004-01-09 | 208 | 255d | 0d |
| 211 | 17.19 | behandeling verzoek voorlopige voorziening |  | 4w | 2004-01-12 | 2004-02-06 | 210 | 255d | 0d |
| 212 | 17.20 | uitspraak Rechbank over bezwaren |  | 1w | 2004-02-09 | 2004-02-13 | 211 | 255d |  |
| 213 | 17.21 | behandeling bezwaarschrift door commissie |  | 10w | 2003-12-01 | 2004-02-06 | 208 | 0d |  |
| 214 | 17.22 | beslissing op bezwaar door gemeenteraad |  | 1w | 2004-02-09 | 2004-02-13 | 213 | 0d |  |
| 215 | 17.23 | bekendmaking beslissing op bezwaren |  | 1w | 2004-02-16 | 2004-02-20 | 214 | 0d |  |
| 216 | 17.24 | beroepsprocedure bij Rechtbank | milestone | 0w | 2004-02-20 | 2004-02-20 | 215 | 0d |  |
| 217 | 17.25 | beroep+verzoek voorl.voorz. Bij rechtbank |  | 4w | 2004-02-23 | 2004-03-19 | 216 | 0d |  |
| 218 | 17.26 | behandeling verzoek voorl.voorz. Bij rechbank |  | 4w | 2004-03-22 | 2004-04-16 | 217 | 0d |  |
| 219 | 17.27 | uitspraak door Pres.rechtbank voorl.voorz. |  | 1w | 2004-04-19 | 2004-04-23 | 218 | 0d |  |
| 220 | 17.28 | beroepsprocedure bij rechtbank |  | 40w | 2004-04-26 | 2005-01-28 | 219 | 0d |  |
| 221 | 17.29 | uitspraak rechtbank over bezwaren |  | 1w | 2005-01-31 | 2005-02-04 | 220 | 0d |  |

| ID | WBS | Task | Type | Duration | Start | Finish | Predecessors | Total slack | Free slack |
| --- | --- | --- | --- | --- | --- | --- | --- | --- | --- |
| 222 | 18 | **beroepsprocedure bij Raad van State** |  | 290d | 2002-12-30 | 2004-02-06 |  | 260d |  |
| 223 | 18.1 | beroep+verzoek voorl.voorz. Bij ABRvS |  | 6w | 2002-12-30 | 2003-02-07 |  | 260d | 0d |
| 224 | 18.2 | behandeling verzoek bij Voorz. ABRvS |  | 13w | 2003-02-10 | 2003-05-09 | 223 | 450d | 0d |
| 225 | 18.3 | uitspraak voorl.voorz. Door Voorz. ABRvS |  | 1w | 2003-05-12 | 2003-05-16 | 224 | 450d |  |
| 226 | 18.4 | beroepsprocedure bij ABRvS |  | 52w | 2003-02-10 | 2004-02-06 | 223 | 260d | 0d |
| 227 | 18.5 | onherropelijke vrijstelling na afwijzing hoger beroep | milestone | 0w | 2004-02-06 | 2004-02-06 | 226 | 260d |  |
| 229 | 19 | **ARTIKEL 2 LID 2 WRO (geen bezwaar)** |  | 130d | 2002-12-30 | 2003-06-27 |  | 420d |  |
| 230 | 19.1 | indiening verzoek om vrijstelling |  | 1w | 2002-12-30 | 2003-01-03 |  | 420d | 0d |
| 231 | 19.2 | principe besluit vrijstellingsprocedure |  | 8w | 2003-01-06 | 2003-02-28 | 230 | 420d | 0d |
| 232 | 19.3 | kennisgeving ter inzage leggen |  | 1w | 2003-03-03 | 2003-03-07 | 231 | 420d | 0d |
| 233 | 19.4 | verzoek vrijstelling ter inzage |  | 1w | 2003-03-10 | 2003-03-14 | 232 | 420d | 0d |
| 234 | 19.5 | indienen zienswijzen ten vrijstelling |  | 4w | 2003-03-10 | 2003-04-04 | 233SS | 460d | 0d |
| 235 | 19.6 | beantwoorden zienswijzen |  | 4w | 2003-04-07 | 2003-05-02 | 234 | 460d |  |
| 236 | 19.7 | behandeling verzoek om vrijstelling |  | 8w | 2003-03-17 | 2003-05-09 | 233 | 420d | 0d |
| 237 | 19.8 | besluit B & W verlenen vrijstelling |  | 1w | 2003-05-12 | 2003-05-16 | 236 | 420d | 0d |
| 238 | 19.9 | bekendmaking primair besluit: rechtkracht | milestone | 0w | 2003-05-16 | 2003-05-16 | 237 | 420d | 0d |
| 239 | 19.10 | termijn van bezwaren |  | 6w | 2003-05-19 | 2003-06-27 | 238 | 420d | 0d |
| 240 | 19.11 | onherroepelijke vrijstelling | milestone | 0w | 2003-06-27 | 2003-06-27 | 239 | 420d |  |
| 242 | 20 | **ARTIKEL 19 LID 2 wro (met bezwaar)** |  | 415d | 2002-12-30 | 2004-07-30 |  | 135d |  |
| 243 | 20.1 | indiening verzoek om vrijstelling |  | 1w | 2002-12-30 | 2003-01-03 |  | 135d | 0d |
| 244 | 20.2 | principe besluit toepassing vrijstelling |  | 8w | 2003-01-06 | 2003-02-28 | 243 | 135d | 0d |
| 245 | 20.3 | kennisgeving ter inzage leggen |  | 1w | 2003-03-03 | 2003-03-07 | 244 | 135d | 0d |
| 246 | 20.4 | ter inzage legging verzoek vrijstelling |  | 1w | 2003-03-10 | 2003-03-14 | 245 | 135d | 0d |
| 247 | 20.5 | indienen zienswijzen tegen plan |  | 4w | 2003-03-10 | 2003-04-04 | 246SS | 460d | 0d |
| 248 | 20.6 | beantwoorden zienswijzen |  | 4w | 2003-04-07 | 2003-05-02 | 247 | 460d |  |
| 249 | 20.7 | behandeling verzoek om vrijstelling |  | 8w | 2003-03-17 | 2003-05-09 | 246 | 135d | 0d |
| 250 | 20.8 | besluit B & W verlenen vrijstelling |  | 1w | 2003-05-12 | 2003-05-16 | 249 | 135d | 0d |
| 251 | 20.9 | bekendmaking primair besluit: rechtkracht | milestone | 0w | 2003-05-16 | 2003-05-16 | 250 | 135d | 0d |
| 252 | 20.10 | termijn van bezwaren |  | 6w | 2003-05-19 | 2003-06-27 | 251 | 370d | 0d |
| 253 | 20.11 | beroepsprocedure bij Pres. Rechtbank | milestone | 0w | 2003-06-27 | 2003-06-27 | 252 | 420d |  |
| 254 | 20.12 | indienen verzoek voorl.voorz. Bij rechtbank |  | 6w | 2003-06-30 | 2003-08-08 | 252 | 370d | 0d |
| 255 | 20.13 | behandeling verzoek voor.voorz. |  | 4w | 2003-08-11 | 2003-09-05 | 254 | 370d | 0d |
| 256 | 20.14 | uitspraak Pres.rechtbank voorl.voorz. | milestone | 0w | 2003-09-05 | 2003-09-05 | 255 | 370d |  |
| 257 | 20.15 | behandeling bezwaarschrift door commissie |  | 10w | 2003-05-19 | 2003-07-25 | 251 | 135d | 0d |
| 258 | 20.16 | beslissing op bezwaar door B & W |  | 1w | 2003-07-28 | 2003-08-01 | 257 | 135d | 0d |
| 259 | 20.17 | bekendmaking beslissing op bezwaar |  | 1w | 2003-08-04 | 2003-08-08 | 258 | 135d | 0d |
| 260 | 20.18 | beroep+verzoek voorl.voorz. Bij rechtbank |  | 6w | 2003-08-11 | 2003-09-19 | 259 | 135d | 0d |
| 261 | 20.19 | behandeling verzoek voorl.voorz. rechtbank |  | 4w | 2003-09-22 | 2003-10-17 | 260 | 135d | 0d |
| 262 | 20.20 | uitspraak door Pres.rechtbank voorl.voorz. |  | 1w | 2003-10-20 | 2003-10-24 | 261 | 135d | 0d |
| 263 | 20.21 | beroepsprocedure bij rechtbank |  | 40w | 2003-10-27 | 2004-07-30 | 262 | 135d |  |

| ID | WBS | Task | Type | Duration | Start | Finish | Predecessors | Total slack | Free slack |
| --- | --- | --- | --- | --- | --- | --- | --- | --- | --- |
| 264 | 21 | **beroepsprocedure bij Raad van State** |  | 355d | 2002-12-30 | 2004-05-07 |  | 195d |  |
| 265 | 21.1 | beroep+verzoek voorl.voorz. Bij ABRvS |  | 6w | 2002-12-30 | 2003-02-07 |  | 195d | 0d |
| 266 | 21.2 | behandeling verzoek voorl.voorz. Bij ABRvS |  | 13w | 2003-02-10 | 2003-05-09 | 265 | 195d | 0d |
| 267 | 21.3 | uitspraak door Voorz. ABRvS |  | 1w | 2003-05-12 | 2003-05-16 | 266 | 450d |  |
| 268 | 21.4 | beroepsprocedure bij ABRvS |  | 52w | 2003-05-12 | 2004-05-07 | 266 | 195d | 0d |
| 269 | 21.5 | onherroepelijke vrijstelling na afwijzing beroep | milestone | 0w | 2004-05-07 | 2004-05-07 | 268 | 195d |  |
| 271 | 22 | **BESTEMMINGSPLAN (geen bezwaren)** |  | 355d | 2002-12-30 | 2004-05-07 |  | 195d |  |
| 272 | 22.1 | milieu effect rapport aanwe (indien nodig) |  | 1w | 2002-12-30 | 2003-01-03 |  | 195d | 0d |
| 273 | 22.2 | voorbereidingen bestemmingsplan |  | 6w | 2003-01-06 | 2003-02-14 | 272 | 195d | 0d |
| 274 | 22.3 | bestuurlijk vooroverleg met instanties |  | 6w | 2003-02-17 | 2003-03-28 | 273 | 195d | 0d |
| 275 | 22.4 | voorontwerp bestemmingsplan |  | 1w | 2003-03-31 | 2003-04-04 | 274 | 195d | 0d |
| 276 | 22.5 | behandeling college B & W en politiek |  | 8w | 2003-04-07 | 2003-05-30 | 275 | 195d | 0d |
| 277 | 22.6 | toezenden aan provincie/ter inzage |  | 2w | 2003-06-02 | 2003-06-13 | 276 | 195d | 0d |
| 278 | 22.7 | inspraakprocedure voorontwerp |  | 4w | 2003-06-16 | 2003-07-11 | 277 | 195d | 0d |
| 279 | 22.8 | behandeling voorontwerp door PPC |  | 4w | 2003-06-16 | 2003-07-11 | 277 | 195d | 0d |
| 280 | 22.9 | verwerken inspraak en vooroverleg |  | 1w | 2003-07-14 | 2003-07-18 | 279, 278 | 195d | 0d |
| 281 | 22.10 | voorbereiding ter inzage leggen |  | 2w | 2003-07-21 | 2003-08-01 | 280 | 195d | 0d |
| 282 | 22.11 | ontwerp bestemmingsplan ter inzage |  | 4w | 2003-08-04 | 2003-08-29 | 281 | 195d | 0d |
| 283 | 22.12 | verwerken zienswijzen |  | 1w | 2003-09-01 | 2003-09-05 | 282 | 195d | 0d |
| 284 | 22.13 | vastslling bestemmingsplan gemeenteraad |  | 8w | 2003-09-08 | 2003-10-31 | 283 | 195d | 0d |
| 285 | 22.14 | toezenden aan GS/kennisgeving ter inzage |  | 4w | 2003-11-03 | 2003-11-28 | 284 | 310d |  |
| 286 | 22.15 | vastgesteld bestemmingsplan ter inzage |  | 4w | 2003-11-03 | 2003-11-28 | 284 | 195d | 0d |
| 287 | 22.16 | goedkeuringsbesluit door GS |  | 1w | 2004-02-23 | 2004-02-27 | 286FS+12w | 195d | 0d |
| 288 | 22.17 | bekendmaking besluit door GS aan gemeente |  | 2w | 2004-03-01 | 2004-03-12 | 287 | 195d | 0d |
| 289 | 22.18 | bekendmaking besluit door gemeente |  | 2w | 2004-03-15 | 2004-03-26 | 288 | 195d | 0d |
| 290 | 22.19 | besluit GS ter inzage door gemeente |  | 1w | 2004-03-29 | 2004-04-02 | 289 | 195d | 0d |
| 291 | 22.20 | beroepstermijn inzake besluit door GS |  | 6w | 2004-03-29 | 2004-05-07 | 290SS | 195d | 0d |
| 292 | 22.21 | bestemmingsplan onherroepelijk | milestone | 0w | 2004-05-07 | 2004-05-07 | 291 | 195d |  |

| ID | WBS | Task | Type | Duration | Start | Finish | Predecessors | Total slack | Free slack |
| --- | --- | --- | --- | --- | --- | --- | --- | --- | --- |
| 294 | 23 | **BESTEMMINGSPLAN (met bezwaren)** |  | 495d | 2002-12-30 | 2004-11-19 |  | 55d |  |
| 295 | 23.1 | milieu effect rapport aanwezig (indien nodig) |  | 1w | 2002-12-30 | 2003-01-03 |  | 55d | 0d |
| 296 | 23.2 | voorbereiden bestemmingsplan |  | 6w | 2003-01-06 | 2003-02-14 | 295 | 55d | 0d |
| 297 | 23.3 | bestuurlijk (voor)overleg met instanties |  | 6w | 2003-02-17 | 2003-03-28 | 296 | 55d | 0d |
| 298 | 23.4 | voorontwerp bestemmingsplan |  | 1w | 2003-03-31 | 2003-04-04 | 297 | 55d | 0d |
| 299 | 23.5 | behandeling in B & W en politiek |  | 8w | 2003-04-07 | 2003-05-30 | 298 | 55d | 0d |
| 300 | 23.6 | toezending aan provincie/ ter inzage leggen |  | 2w | 2003-06-02 | 2003-06-13 | 299 | 55d | 0d |
| 301 | 23.7 | inspraakprocedure voorontwerp |  | 4w | 2003-06-16 | 2003-07-11 | 300 | 55d | 0d |
| 302 | 23.8 | behandeling voorontwerp door PPC |  | 4w | 2003-06-16 | 2003-07-11 | 300 | 55d | 0d |
| 303 | 23.9 | verwerken inspraak en vooroverleg |  | 6w | 2003-07-14 | 2003-08-22 | 302, 301 | 55d | 0d |
| 304 | 23.10 | voorbereiding ter inzage leggen |  | 2w | 2003-08-25 | 2003-09-05 | 303 | 55d | 0d |
| 305 | 23.11 | ontwerp bestemmingsplan ter inzage |  | 4w | 2003-09-08 | 2003-10-03 | 304 | 55d | 0d |
| 306 | 23.12 | verwerken zienswijzen en opstellen nota |  | 6w | 2003-10-06 | 2003-11-14 | 305 | 320d |  |
| 307 | 23.13 | vasstellen bestemmingsplan gemeenteraad | milestone | 0w | 2004-02-06 | 2004-02-06 | 305FS+18w | 55d | 0d |
| 308 | 23.14 | toezenden bestemmingsplan aan GS |  | 4w | 2004-02-09 | 2004-03-05 | 307 | 55d | 0d |
| 309 | 23.15 | vastgesteld bestemmingsplan ter inzage |  | 4w | 2004-03-08 | 2004-04-02 | 308 | 220d |  |
| 310 | 23.16 | goedkeuringsbesluit door GS |  | 1w | 2004-09-06 | 2004-09-10 | 308FS+26w | 55d | 0d |
| 311 | 23.17 | bekendmaking besluit GS aan gemeente |  | 2w | 2004-09-13 | 2004-09-24 | 310 | 55d | 0d |
| 312 | 23.18 | bekendmaking besluit GS door gemeente |  | 2w | 2004-09-27 | 2004-10-08 | 311 | 55d | 0d |
| 313 | 23.19 | besluit GS door gemeente ter inzage |  | 1w | 2004-10-11 | 2004-10-15 | 312 | 55d | 0d |
| 314 | 23.20 | beroepstermijn inzake besluit door GS |  | 6w | 2004-10-11 | 2004-11-19 | 313SS | 55d |  |
| 315 | 24 | **beroepsprocedure bij Raad van State** |  | 270d | 2002-12-30 | 2004-01-09 |  | 280d |  |
| 316 | 24.1 | beroep+verzoek voorl.voorz. Bij ABRvS |  | 1w | 2002-12-30 | 2003-01-03 |  | 280d | 0d |
| 317 | 24.2 | behandeling verzoek voorl.voorz. ABRvS |  | 13w | 2003-01-06 | 2003-04-04 | 316 | 470d | 0d |
| 318 | 24.3 | uitspraak over voorl.voorz. Door ABRvS |  | 1w | 2003-04-07 | 2003-04-11 | 317 | 470d | 0d |
| 319 | 24.4 | van kracht zijnd bestemmingsplan |  | 1w | 2003-04-14 | 2003-04-18 | 318 | 470d |  |
| 320 | 24.5 | beroepsprocedure bij ABRvS |  | 52w | 2003-01-06 | 2004-01-02 | 316 | 280d | 0d |
| 321 | 24.6 | uitspraak verwerping beroep |  | 1w | 2004-01-05 | 2004-01-09 | 320 | 280d | 0d |
| 322 | 24.7 | bestemmingsplan onherroepelijk | milestone | 0w | 2004-01-09 | 2004-01-09 | 321 | 280d |  |
